# YMorinSem3

How a schedule from MS Project changed from version to version. A marks actual dates.

## Version 1 (data date 2002-02-09, saved 2002-02-10, file moriny_03.mpp)

| ID | WBS | Task | Duration | Start | Finish | Predecessors | Total float | Constraint |
| --- | --- | --- | --- | --- | --- | --- | --- | --- |
| 1 | 1 | **Introduction en entreprise** | 1d | 2002-01-21 09:00 | 2002-01-21 17:00 |  | 2.29d |  |
| 2 |  | Apprentissage de l'environnement Visual Basic | 3.5h | 2002-01-21 09:00 | 2002-01-21 13:30 |  | 2.29d |  |
| 3 |  | Apprentissage de la programme en Visual Basic | 3.5h | 2002-01-21 13:30 | 2002-01-21 17:00 | 2 | 2.29d |  |
| 5 | 2 | **Analyse** | 7d | 2002-01-22 09:00 | 2002-01-31 17:00 | 1 | 2.29d |  |
| 6 | 2.1 | **Analyse avant la rencontre** | 2d | 2002-01-22 09:00 | 2002-01-23 17:00 |  | 2.29d |  |
| 7 |  | Aperçu du programme de gestion actuel | 3.5h | 2002-01-22 09:00 | 2002-01-22 13:30 |  | 2.29d |  |
| 8 |  | Description du programme de gestion | 3.5h | 2002-01-22 13:30 | 2002-01-22 17:00 | 7 | 2.29d |  |
| 9 |  | Documentation du programme de gestion actuel | 3.5h | 2002-01-23 09:00 | 2002-01-23 13:30 | 8 | 2.29d |  |
| 10 |  | Rencontre avec l'usager du programme | 3.5h | 2002-01-23 13:30 | 2002-01-23 17:00 | 9 | 2.29d |  |
| 11 | 2.2 | **Analyse après la rencontre** | 4d | 2002-01-24 09:00 | 2002-01-30 17:00 | 10 | 2.29d |  |
| 12 |  | Documentation (brouillon) de la rencontre | 3.5h | 2002-01-24 09:00 | 2002-01-24 13:30 |  | 2.29d |  |
| 13 |  | Schématisation (brouillon avec Word) de la rencontre | 3.5h | 2002-01-24 13:30 | 2002-01-24 17:00 | 12 | 2.29d |  |
| 14 |  | Description des tables | 1.5h | 2002-01-28 09:00 | 2002-01-28 10:30 | 13 | 2.29d |  |
| 15 |  | Description des champs | 3.5h | 2002-01-28 10:30 | 2002-01-28 15:00 | 14 | 2.29d |  |
| 16 |  | Descriptions des relations | 3h | 2002-01-28 15:00 | 2002-01-29 10:00 | 15 | 2.29d |  |
| 17 |  | Retour sur EAX et sur DFD | 1h | 2002-01-29 10:00 | 2002-01-29 11:00 | 16 | 2.29d |  |
| 18 |  | Préparation du modèle EAX | 3h | 2002-01-29 11:00 | 2002-01-29 15:00 | 17 | 2.29d |  |
| 19 |  | Séparation du modèle EAX (en 4) | 2h | 2002-01-29 15:00 | 2002-01-29 17:00 | 18 | 2.29d |  |
| 20 |  | Préparation de 3 modèles DFD | 2h | 2002-01-30 09:00 | 2002-01-30 11:00 | 19 | 2.29d |  |
| 21 |  | Vérification des tables | 1h | 2002-01-30 11:00 | 2002-01-30 12:00 | 20 | 2.29d |  |
| 22 |  | Vérification des champs | 3.5h | 2002-01-30 13:00 | 2002-01-30 16:30 | 21 | 2.29d |  |
| 23 |  | Vérification des relations | 30min | 2002-01-30 16:30 | 2002-01-30 17:00 | 22 | 2.29d |  |
| 24 | 2.3 | **Présentation de l'analyse** | 1d | 2002-01-31 09:00 | 2002-01-31 17:00 | 23 | 2.29d |  |
| 25 |  | Préparation de la présentation PowerPoint | 3h | 2002-01-31 09:00 | 2002-01-31 12:00 |  | 2.29d |  |
| 26 |  | Correction finale et ajustement | 2h | 2002-01-31 13:00 | 2002-01-31 15:00 | 25 | 2.29d |  |
| 27 |  | Présentation (Comptable et Directeur du Marketing) | 2h | 2002-01-31 15:00 | 2002-01-31 17:00 | 26 | 2.29d |  |
| 29 | 3 | **Conception** | 8d | 2002-02-04 09:00 | 2002-02-14 17:00 | 5 | 2.29d |  |
| 30 |  | Programmation WEB - Javascript | 2h | 2002-02-04 09:00 | 2002-02-04 11:00 |  | 2.29d | start no earlier than 2002-02-04 09:00 |
| 31 | 3.2 | **Ébauche du logiciel** | 5d | 2002-02-04 11:00 | 2002-02-12 11:00 |  | 2.29d |  |
| 32 |  | Fenêtre principale | 3h | 2002-02-04 11:00 | 2002-02-04 15:00 | 30 | 2.29d |  |
| 33 |  | Fenêtre de démarrage | 3h | 2002-02-04 15:00 | 2002-02-05 10:00 | 32 | 2.29d |  |
| 34 |  | Fenêtres de recherche | 1.5h | 2002-02-05 10:00 | 2002-02-05 11:30 | 33 | 2.29d |  |
| 35 |  | Fenêtres des modes de paiement | 3h | 2002-02-05 11:30 | 2002-02-05 15:30 | 34 | 2.29d |  |
| 36 |  | Fenêtre des protocoles | 3h | 2002-02-05 15:30 | 2002-02-06 10:30 | 35 | 2.29d |  |
| 37 |  | Fenêtre des frais | 3h | 2002-02-06 10:30 | 2002-02-06 14:30 | 36 | 2.29d |  |
| 38 |  | Fenêtre des recettes | 3h | 2002-02-06 14:30 | 2002-02-07 09:30 | 37 | 2.29d |  |
| 39 |  | Fenêtre des déboursés | 3h | 2002-02-07 09:30 | 2002-02-07 13:30 | 38 | 2.29d |  |
| 40 |  | Fenêtre de résumé | 2h | 2002-02-07 13:30 | 2002-02-07 15:30 | 39 | 2.29d |  |
| 41 |  | Retour sur l'analyse | 3.5h | 2002-02-07 15:30 | 2002-02-11 11:00 | 40 | 2.29d |  |
| 42 |  | Retour sur l'aspect graphique | 3.5h | 2002-02-11 11:00 | 2002-02-11 15:30 | 41 | 2.29d |  |
| 43 |  | Uniformisation | 3.5h | 2002-02-11 15:30 | 2002-02-12 11:00 | 42 | 2.29d |  |
| 44 | 3.3 | **Recherche des composantes** | 1.07d | 2002-02-12 11:00 | 2002-02-13 11:30 | 43 | 2.29d |  |
| 45 |  | Icones et dessins | 3.5h | 2002-02-12 11:00 | 2002-02-12 15:30 |  | 2.29d |  |
| 46 |  | Composantes OCX pour les grilles | 2h | 2002-02-12 15:30 | 2002-02-13 09:30 | 45 | 2.29d |  |
| 47 |  | Formation sur les composantes de l'usager | 2h | 2002-02-13 09:30 | 2002-02-13 11:30 | 46 | 2.29d |  |
| 48 |  | Présentation de la première ébauche | 3.5h | 2002-02-13 11:30 | 2002-02-13 16:00 | 47 | 2.29d |  |
| 49 | 3.5 | **Aide à la technicienne de laboratoire** | 1.14d | 2002-02-13 16:00 | 2002-02-14 17:00 | 48 | 2.29d |  |
| 50 |  | Publi-postage Word | 3h | 2002-02-13 16:00 | 2002-02-14 11:00 |  | 2.29d |  |
| 51 |  | Introduction à Excel | 3h | 2002-02-14 11:00 | 2002-02-14 15:00 | 50 | 2.29d |  |
| 52 |  | Introduction à la numérisation | 2h | 2002-02-14 15:00 | 2002-02-14 17:00 | 51 | 2.29d |  |
| 55 | 4 | **Deuxième ébauche du logiciel** | 2.5d | 2002-02-18 09:00 | 2002-02-20 13:30 | 49 | 2.29d |  |
| 56 |  | Documentation des améliorations à apporter | 3.5h | 2002-02-18 09:00 | 2002-02-18 13:30 |  | 2.29d |  |
| 57 |  | Modification des formulaires | 3.5h | 2002-02-18 13:30 | 2002-02-18 17:00 | 56 | 2.29d |  |
| 58 |  | Ajout/suppresion de formulaires | 3.5h | 2002-02-19 09:00 | 2002-02-19 13:30 | 57 | 2.29d |  |
| 59 |  | Finalisation du logiciel de démonstration | 3.5h | 2002-02-19 13:30 | 2002-02-19 17:00 | 58 | 2.29d |  |
| 60 |  | Présentation du logiciel de démonstration corrigé | 3.5h | 2002-02-20 09:00 | 2002-02-20 13:30 | 59 | 2.29d |  |
| 62 | 5 | **Conception détaillée** | 9.5d | 2002-02-20 13:30 | 2002-03-07 17:00 | 60 | 2.29d |  |
| 63 |  | Discussion sur les rapports et accesibilité | 3.5h | 2002-02-20 13:30 | 2002-02-20 17:00 |  | 2.29d |  |
| 64 |  | Discusion sur les requêtes | 3.5h | 2002-02-21 09:00 | 2002-02-21 13:30 | 63 | 2.29d |  |
| 65 |  | Réflexion sur les requêtes | 3.5h | 2002-02-21 13:30 | 2002-02-21 17:00 | 64 | 2.29d |  |
| 66 |  | Discusion sur les résultats attendus | 3.5h | 2002-02-25 09:00 | 2002-02-25 13:30 | 65 | 2.29d |  |
| 67 |  | Discusion sur le système - Infirmière | 3.5h | 2002-02-25 13:30 | 2002-02-25 17:00 | 66 | 2.29d |  |
| 68 |  | Discusion sur le logiciel de programmation | 3.5h | 2002-02-26 09:00 | 2002-02-26 13:30 | 67 | 2.29d |  |
| 69 | 5.7 | **Apprentissage** | 3.29d | 2002-02-26 13:30 | 2002-03-04 15:30 | 68 | 2.29d |  |
| 70 |  | 1- Logiciel | 3.5h | 2002-02-26 13:30 | 2002-02-26 17:00 |  | 2.29d |  |
| 71 |  | 2- Exemples, tutoriels | 3.5h | 2002-02-27 09:00 | 2002-02-27 13:30 | 70 | 2.29d |  |
| 72 |  | 3- Convention, normes de travail | 3.5h | 2002-02-27 13:30 | 2002-02-27 17:00 | 71 | 2.29d |  |
| 73 |  | 4- Classe | 3.5h | 2002-02-28 09:00 | 2002-02-28 13:30 | 72 | 2.29d |  |
| 74 |  | 5- Modules | 2h | 2002-02-28 13:30 | 2002-02-28 15:30 | 73 | 2.29d |  |
| 75 |  | 6- Composantes VB | 3.5h | 2002-02-28 15:30 | 2002-03-04 11:00 | 74 | 2.29d |  |

| ID | WBS | Task | Duration | Start | Finish | Predecessors | Total float | Constraint |
| --- | --- | --- | --- | --- | --- | --- | --- | --- |
| 76 |  | 7- Accès à la base de données | 3.5h | 2002-03-04 11:00 | 2002-03-04 15:30 | 75 | 2.29d |  |
| 77 | 5.8 | **Base de données** | 2.21d | 2002-03-04 15:30 | 2002-03-06 17:00 | 69 | 2.29d |  |
| 78 |  | Structuration de la base de données | 2h | 2002-03-04 15:30 | 2002-03-05 09:30 |  | 2.29d |  |
| 79 |  | Ajouts des descriptions | 3.5h | 2002-03-05 09:30 | 2002-03-05 14:00 | 78 | 2.29d |  |
| 80 |  | Confirmité des noms | 2.5h | 2002-03-05 14:00 | 2002-03-05 16:30 | 79 | 2.29d |  |
| 81 |  | Valeurs par défaut/fonctions | 2h | 2002-03-05 16:30 | 2002-03-06 10:30 | 80 | 2.29d |  |
| 82 |  | Format des champs | 2h | 2002-03-06 10:30 | 2002-03-06 13:30 | 81 | 2.29d |  |
| 83 |  | Visibilité et accesibilité | 3.5h | 2002-03-06 13:30 | 2002-03-06 17:00 | 82 | 2.29d |  |
| 84 |  | Support technique | 3.5h | 2002-03-07 09:00 | 2002-03-07 13:30 | 77 | 2.29d |  |
| 85 |  | Imprévus | 3.5h | 2002-03-07 13:30 | 2002-03-07 17:00 | 84 | 2.29d |  |
| 87 |  | Codage | 26d | 2002-03-11 09:00 | 2002-04-10 16:00 | 62 | 1.14d | start no earlier than 2002-03-11 09:00 |
| 89 |  | Test | 6d | 2002-04-15 09:00 | 2002-04-22 11:00 | 87 | 0d | start no earlier than 2002-04-15 09:00 |
| 91 |  | Implantation | 4d | 2002-04-22 11:00 | 2002-04-25 16:00 | 89 | 0d |  |
| 93 |  | Vérification et documentation | 8d | 2002-04-25 16:00 | 2002-05-06 16:00 | 91 | 0d |  |

## Version 2 (data date 2002-02-09, saved 2002-02-12, file moriny_03-2.mpp)

Last finish 2002-05-06 → 2002-05-02 (-4d). Complete tasks 0 → 25.

Changed:

| ID | Task | Start | Finish | Duration | Complete | Total float | Other |
| --- | --- | --- | --- | --- | --- | --- | --- |
| 1 | **Introduction en entreprise** | 2002-01-21 09:00 A | 2002-01-21 17:00 A |  | 0% → 100% | 2.29d → none | resources Yan Morin → none |
| 2 | Apprentissage de l'environnement Visual Basic | 2002-01-21 09:00 A | 2002-01-21 13:30 A |  | 0% → 100% | 2.29d → none | resources none → Boris Nacinovic; Yan Morin |
| 3 | Apprentissage de la programme en Visual Basic | 2002-01-21 13:30 A | 2002-01-21 17:00 A |  | 0% → 100% | 2.29d → none | resources none → Yan Morin |
| 5 | **Analyse** | 2002-01-22 09:00 A | 2002-01-31 17:00 A |  | 0% → 100% | 2.29d → none | resources Yan Morin → none |
| 6 | **Analyse avant la rencontre** | 2002-01-22 09:00 A | 2002-01-23 17:00 → 2002-01-23 16:00 A | 2d → 1.86d | 0% → 100% | 2.29d → none |  |
| 7 | Aperçu du programme de gestion actuel | 2002-01-22 09:00 A | 2002-01-22 13:30 A |  | 0% → 100% | 2.29d → none | resources none → Yan Morin |
| 8 | Description du programme de gestion | 2002-01-22 13:30 A | 2002-01-22 17:00 A |  | 0% → 100% | 2.29d → none | resources none → Yan Morin |
| 9 | Documentation du programme de gestion actuel | 2002-01-23 09:00 → 2002-01-23 08:00 A | 2002-01-23 13:30 A |  | 0% → 100% | 2.29d → none | resources none → Yan Morin |
| 10 | Rencontre avec l'usager du programme | 2002-01-23 13:30 → 2002-01-23 11:30 A | 2002-01-23 17:00 → 2002-01-23 16:00 A |  | 0% → 100% | 2.29d → none | resources none → Yan Morin; Emmanuelle Forger - Comptable; Boris Nacinovic |
| 11 | **Analyse après la rencontre** | 2002-01-24 09:00 A | 2002-01-30 17:00 A |  | 0% → 100% | 2.29d → none |  |
| 12 | Documentation (brouillon) de la rencontre | 2002-01-24 09:00 A | 2002-01-24 13:30 A |  | 0% → 100% | 2.29d → none | constraint none → start no earlier than 2002-01-24 09:00; resources none → Yan Morin |
| 13 | Schématisation (brouillon avec Word) de la rencontre | 2002-01-24 13:30 A | 2002-01-24 17:00 A |  | 0% → 100% | 2.29d → none | resources none → Yan Morin |
| 14 | Description des tables | 2002-01-28 09:00 A | 2002-01-28 10:30 A |  | 0% → 100% | 2.29d → none | resources none → Yan Morin |
| 15 | Description des champs | 2002-01-28 10:30 A | 2002-01-28 15:00 A |  | 0% → 100% | 2.29d → none | resources none → Yan Morin |
| 16 | Descriptions des relations | 2002-01-28 15:00 A | 2002-01-29 10:00 A |  | 0% → 100% | 2.29d → none | resources none → Yan Morin |
| 17 | Retour sur EAX et sur DFD | 2002-01-29 10:00 A | 2002-01-29 11:00 A |  | 0% → 100% | 2.29d → none | resources none → Yan Morin |
| 18 | Préparation du modèle EAX | 2002-01-29 11:00 A | 2002-01-29 15:00 A |  | 0% → 100% | 2.29d → none | resources none → Yan Morin |
| 19 | Séparation du modèle EAX (en 4) | 2002-01-29 15:00 A | 2002-01-29 17:00 A |  | 0% → 100% | 2.29d → none | resources none → Yan Morin |
| 20 | Préparation de 3 modèles DFD | 2002-01-30 09:00 A | 2002-01-30 11:00 A |  | 0% → 100% | 2.29d → none | resources none → Yan Morin |
| 21 | Vérification des tables | 2002-01-30 11:00 A | 2002-01-30 12:00 A |  | 0% → 100% | 2.29d → none | resources none → Yan Morin |
| 22 | Vérification des champs | 2002-01-30 13:00 A | 2002-01-30 16:30 A |  | 0% → 100% | 2.29d → none | resources none → Yan Morin |
| 23 | Vérification des relations | 2002-01-30 16:30 A | 2002-01-30 17:00 A |  | 0% → 100% | 2.29d → none | resources none → Yan Morin |
| 24 | **Présentation de l'analyse** | 2002-01-31 09:00 A | 2002-01-31 17:00 A |  | 0% → 100% | 2.29d → none |  |
| 25 | Préparation de la présentation PowerPoint | 2002-01-31 09:00 A | 2002-01-31 12:00 A |  | 0% → 100% | 2.29d → none | resources none → Yan Morin |
| 26 | Correction finale et ajustement | 2002-01-31 13:00 A | 2002-01-31 15:00 A |  | 0% → 100% | 2.29d → none | resources none → Yan Morin |
| 27 | Présentation (Comptable et Directeur du Marketing) | 2002-01-31 15:00 A | 2002-01-31 17:00 A |  | 0% → 100% | 2.29d → none | resources none → Yan Morin; Boris Nacinovic; Emmanuelle Forger - Comptable; Gilles Juteau - Vice-président, directeur marketing |
| 29 | **Conception** | 2002-02-04 09:00 A |  |  | 0% → 60% | 2.29d → 44d |  |
| 30 | Programmation WEB - Javascript | 2002-02-04 09:00 A | 2002-02-04 11:00 A |  | 0% → 100% | 2.29d → none |  |
| 31 | **Ébauche du logiciel** | 2002-02-04 11:00 A |  |  | 0% → 51% | 2.29d → 4.3d |  |
| 32 | Fenêtre principale | 2002-02-04 11:00 A |  |  | 0% → 60% | 2.29d → 6.58d |  |
| 33 | Fenêtre de démarrage | 2002-02-04 15:00 A |  |  | 0% → 60% | 2.29d → 6.32d |  |
| 34 | Fenêtres de recherche | 2002-02-05 10:00 A |  |  | 0% → 80% | 2.29d → 6.15d |  |
| 35 | Fenêtres des modes de paiement | 2002-02-05 11:30 A |  |  | 0% → 60% | 2.29d → 5.89d |  |
| 36 | Fenêtre des protocoles | 2002-02-05 15:30 A |  |  | 0% → 90% | 2.29d → 5.51d |  |
| 37 | Fenêtre des frais | 2002-02-06 10:30 A |  |  | 0% → 80% | 2.29d → 5.17d |  |
| 38 | Fenêtre des recettes | 2002-02-06 14:30 A |  |  | 0% → 60% | 2.29d → 4.91d |  |
| 39 | Fenêtre des déboursés | 2002-02-07 09:30 A |  |  | 0% → 65% | 2.29d → 4.63d |  |
| 42 | Retour sur l'aspect graphique | 2002-02-11 11:00 A |  |  | 0% → 33% | 2.29d → 4.46d |  |
| 43 | Uniformisation | 2002-02-11 15:30 A |  |  | 0% → 33% | 2.29d → 4.3d |  |
| 44 | **Recherche des composantes** | 2002-02-12 11:00 A |  |  | 0% → 76% | 2.29d → 0.86d |  |
| 45 | Icones et dessins | 2002-02-12 11:00 A |  |  | 0% → 60% | 2.29d → 4.51d |  |
| 46 | Composantes OCX pour les grilles | 2002-02-12 15:30 A |  |  | 0% → 90% | 2.29d → 4.26d |  |
| 47 | Formation sur les composantes de l'usager | 2002-02-13 09:30 A |  |  | 0% → 90% | 2.29d → 0.86d |  |
| 49 | **Aide à la technicienne de laboratoire** | 2002-02-13 16:00 A | 2002-02-14 17:00 A |  | 0% → 100% | 2.29d → none |  |
| 50 | Publi-postage Word | 2002-02-13 16:00 A | 2002-02-14 11:00 A |  | 0% → 100% | 2.29d → none |  |
| 51 | Introduction à Excel | 2002-02-14 11:00 A | 2002-02-14 15:00 A |  | 0% → 100% | 2.29d → none |  |
| 52 | Introduction à la numérisation | 2002-02-14 15:00 A | 2002-02-14 17:00 A |  | 0% → 100% | 2.29d → none |  |
| 87 | Codage |  | 2002-04-10 16:00 → 2002-04-04 17:00 (-6d) | 26d → 16d |  | 1.14d → 4d |  |
| 89 | Test |  | 2002-04-22 11:00 → 2002-04-17 13:30 (-5d) | 6d → 2.5d |  |  |  |
| 91 | Implantation | 2002-04-22 11:00 → 2002-04-17 13:30 (-5d) | 2002-04-25 16:00 → 2002-04-22 17:00 (-3d) | 4d → 2.5d |  |  |  |
| 93 | Vérification et documentation | 2002-04-25 16:00 → 2002-04-23 09:00 (-2d) | 2002-05-06 16:00 → 2002-05-02 17:00 (-4d) | 8d → 7d |  |  |  |

## Version 3 (data date 2002-02-09, saved 2002-02-23, file moriny_05.mpp)

Last finish stays 2002-05-02. Complete tasks 25 → 53.

Added:

| ID | Task | Duration | Start | Finish | Predecessors | Constraint |
| --- | --- | --- | --- | --- | --- | --- |
| 44 | Fenêtre de résumé et d'impression | 3.5h | 2002-02-12 11:00 A | 2002-02-12 15:30 A | 43 |  |
| 49 | Recherche de pilotes et de script Visual Basic | 3h | 2002-02-12 11:00 A | 2002-02-12 15:00 A | 48 |  |
| 61 | Système de gestion des bonis de rendement des infirmière | 1h | 2002-02-20 13:30 A | 2002-02-20 14:30 A | 60 |  |
| 62 | Documentation, analyse, modification de la base de données | 2h | 2002-02-20 14:30 A | 2002-02-20 16:30 A | 61 |  |
| 63 | Attente de clarification et de réponse sur les infirmière | 2h | 2002-02-21 10:00 A | 2002-02-21 12:00 A | 62 |  |
| 64 | Rencontre finale sur le module "infirmière" | 1.5h | 2002-02-21 14:30 A | 2002-02-21 16:00 A | 63 |  |
| 67 | **Formation 2** | 0.14d | 2002-02-21 09:00 A | 2002-02-21 10:00 A | 64 |  |
| 68 | Excel (pied de page, feuille et zone d'impression) | 1h | 2002-02-21 09:00 A | 2002-02-21 10:00 A |  | start no earlier than 2002-02-23 09:00 |
| 69 | Word (case à cocher, caractères spéciaux, archivage Winzip) | 1h | 2002-02-21 09:00 A | 2002-02-21 10:00 A | 68 | start no earlier than 2002-02-23 09:00 |

Changed:

| ID | Task | Start | Finish | Duration | Complete | Total float | Predecessors | Other |
| --- | --- | --- | --- | --- | --- | --- | --- | --- |
| 1 | **Introduction en entreprise** |  |  |  |  |  |  | baseline start none → 2002-01-21 09:00; baseline finish none → 2002-01-21 17:00 |
| 2 | Apprentissage de l'environnement Visual Basic |  |  |  |  |  |  | baseline start none → 2002-01-21 09:00; baseline finish none → 2002-01-21 13:30 |
| 3 | Apprentissage de la programme en Visual Basic |  |  |  |  |  |  | baseline start none → 2002-01-21 13:30; baseline finish none → 2002-01-21 17:00 |
| 5 | **Analyse** |  |  |  |  |  |  | baseline start none → 2002-01-22 09:00; baseline finish none → 2002-01-31 17:00 |
| 6 | **Analyse avant la rencontre** |  |  |  |  |  |  | baseline start none → 2002-01-22 09:00; baseline finish none → 2002-01-23 16:00 |
| 7 | Aperçu du programme de gestion actuel |  |  |  |  |  |  | baseline start none → 2002-01-22 09:00; baseline finish none → 2002-01-22 13:30 |
| 8 | Description du programme de gestion |  |  |  |  |  |  | baseline start none → 2002-01-22 13:30; baseline finish none → 2002-01-22 17:00 |
| 9 | Documentation du programme de gestion actuel |  |  |  |  |  |  | baseline start none → 2002-01-23 08:00; baseline finish none → 2002-01-23 13:30 |
| 10 | Rencontre avec l'usager du programme |  |  |  |  |  |  | baseline start none → 2002-01-23 11:30; baseline finish none → 2002-01-23 16:00 |
| 11 | **Analyse après la rencontre** |  |  |  |  |  |  | baseline start none → 2002-01-24 09:00; baseline finish none → 2002-01-30 17:00 |
| 12 | Documentation (brouillon) de la rencontre |  |  |  |  |  |  | baseline start none → 2002-01-24 09:00; baseline finish none → 2002-01-24 13:30 |
| 13 | Schématisation (brouillon avec Word) de la rencontre |  |  |  |  |  |  | baseline start none → 2002-01-24 13:30; baseline finish none → 2002-01-24 17:00 |
| 14 | Description des tables |  |  |  |  |  |  | baseline start none → 2002-01-28 09:00; baseline finish none → 2002-01-28 10:30 |
| 15 | Description des champs |  |  |  |  |  |  | baseline start none → 2002-01-28 10:30; baseline finish none → 2002-01-28 15:00 |
| 16 | Descriptions des relations |  |  |  |  |  |  | baseline start none → 2002-01-28 15:00; baseline finish none → 2002-01-29 10:00 |
| 17 | Retour sur EAX et sur DFD |  |  |  |  |  |  | baseline start none → 2002-01-29 10:00; baseline finish none → 2002-01-29 11:00 |
| 18 | Préparation du modèle EAX |  |  |  |  |  |  | baseline start none → 2002-01-29 11:00; baseline finish none → 2002-01-29 15:00 |
| 19 | Séparation du modèle EAX (en 4) |  |  |  |  |  |  | baseline start none → 2002-01-29 15:00; baseline finish none → 2002-01-29 17:00 |
| 20 | Préparation de 3 modèles DFD |  |  |  |  |  |  | baseline start none → 2002-01-30 09:00; baseline finish none → 2002-01-30 11:00 |
| 21 | Vérification des tables |  |  |  |  |  |  | baseline start none → 2002-01-30 11:00; baseline finish none → 2002-01-30 12:00 |
| 22 | Vérification des champs |  |  |  |  |  |  | baseline start none → 2002-01-30 13:00; baseline finish none → 2002-01-30 16:30 |
| 23 | Vérification des relations |  |  |  |  |  |  | baseline start none → 2002-01-30 16:30; baseline finish none → 2002-01-30 17:00 |
| 24 | **Présentation de l'analyse** |  |  |  |  |  |  | baseline start none → 2002-01-31 09:00; baseline finish none → 2002-01-31 17:00 |
| 25 | Préparation de la présentation PowerPoint |  |  |  |  |  |  | baseline start none → 2002-01-31 09:00; baseline finish none → 2002-01-31 12:00 |
| 26 | Correction finale et ajustement |  |  |  |  |  |  | baseline start none → 2002-01-31 13:00; baseline finish none → 2002-01-31 15:00 |
| 27 | Présentation (Comptable et Directeur du Marketing) |  |  |  |  |  |  | baseline start none → 2002-01-31 15:00; baseline finish none → 2002-01-31 17:00 |
| 29 | **Conception** |  |  |  | 60% → 99% | 44d → 0d |  | baseline start none → 2002-02-04 09:00; baseline finish none → 2002-02-14 17:00 |
| 30 | Programmation WEB - Javascript |  |  |  |  |  |  | baseline start none → 2002-02-04 09:00; baseline finish none → 2002-02-04 11:00 |
| 31 | **Ébauche du logiciel** |  | 2002-02-12 11:00 → 2002-02-12 15:30 A | 5d → 5.5d | 51% → 100% | 4.3d → none |  | baseline start none → 2002-02-04 11:00; baseline finish none → 2002-02-12 15:30 |
| 32 | Fenêtre principale |  | 2002-02-04 15:00 A |  | 60% → 100% | 6.58d → none |  | baseline start none → 2002-02-04 11:00; baseline finish none → 2002-02-04 15:00 |
| 33 | Fenêtre de démarrage |  | 2002-02-05 10:00 A |  | 60% → 100% | 6.32d → none |  | baseline start none → 2002-02-04 15:00; baseline finish none → 2002-02-05 10:00 |
| 34 | Fenêtres de recherche |  | 2002-02-05 11:30 A |  | 80% → 100% | 6.15d → none |  | baseline start none → 2002-02-05 10:00; baseline finish none → 2002-02-05 11:30 |
| 35 | Fenêtres des modes de paiement |  | 2002-02-05 15:30 A |  | 60% → 100% | 5.89d → none |  | baseline start none → 2002-02-05 11:30; baseline finish none → 2002-02-05 15:30 |
| 36 | Fenêtre des protocoles |  | 2002-02-06 10:30 A |  | 90% → 100% | 5.51d → none |  | baseline start none → 2002-02-05 15:30; baseline finish none → 2002-02-06 10:30 |
| 37 | Fenêtre des frais |  | 2002-02-06 14:30 A |  | 80% → 100% | 5.17d → none |  | baseline start none → 2002-02-06 10:30; baseline finish none → 2002-02-06 14:30 |
| 38 | Fenêtre des recettes |  | 2002-02-07 09:30 A |  | 60% → 100% | 4.91d → none |  | baseline start none → 2002-02-06 14:30; baseline finish none → 2002-02-07 09:30 |
| 39 | Fenêtre des déboursés |  | 2002-02-07 13:30 A |  | 65% → 100% | 4.63d → none |  | baseline start none → 2002-02-07 09:30; baseline finish none → 2002-02-07 13:30 |
| 40 | Fenêtre de résumé | 2002-02-07 13:30 A | 2002-02-07 15:30 A |  | 0% → 100% | 4.63d → none |  | baseline start none → 2002-02-07 13:30; baseline finish none → 2002-02-07 15:30 |
| 41 | Retour sur l'analyse | 2002-02-07 15:30 A | 2002-02-11 11:00 A |  | 0% → 100% | 4.63d → none |  | baseline start none → 2002-02-07 15:30; baseline finish none → 2002-02-11 11:00 |
| 42 | Retour sur l'aspect graphique |  | 2002-02-11 15:30 A |  | 33% → 100% | 4.46d → none |  | baseline start none → 2002-02-11 11:00; baseline finish none → 2002-02-11 15:30 |
| 43 | Uniformisation |  | 2002-02-12 11:00 A |  | 33% → 100% | 4.3d → none |  | baseline start none → 2002-02-11 15:30; baseline finish none → 2002-02-12 11:00 |
| 45 | **Recherche des composantes** |  | 2002-02-13 11:30 A |  | 76% → 100% | 0.86d → none | 43 → 31 | baseline start none → 2002-02-12 11:00; baseline finish none → 2002-02-13 11:30 |
| 46 | Icones et dessins |  | 2002-02-12 15:30 A |  | 60% → 100% | 4.51d → none |  | baseline start none → 2002-02-12 11:00; baseline finish none → 2002-02-12 15:30 |
| 47 | Composantes OCX pour les grilles |  | 2002-02-13 09:30 A |  | 90% → 100% | 4.26d → none |  | baseline start none → 2002-02-12 15:30; baseline finish none → 2002-02-13 09:30 |
| 48 | Formation sur les composantes de l'usager |  | 2002-02-13 11:30 A |  | 90% → 100% | 0.86d → none |  | baseline start none → 2002-02-13 09:30; baseline finish none → 2002-02-13 11:30 |
| 50 | Présentation de la première ébauche | 2002-02-13 11:30 → 2002-02-12 15:00 A (-1d) | 2002-02-13 16:00 → 2002-02-13 10:30 A |  | 0% → 100% | 0.86d → none | 48 → 49 | baseline start none → 2002-02-12 15:00; baseline finish none → 2002-02-13 10:30 |
| 51 | **Aide et support technique** |  |  |  |  |  | 50 → 45 | was named Aide à la technicienne de laboratoire; baseline start none → 2002-02-13 16:00; baseline finish none → 2002-02-14 17:00 |
| 52 | Publi-postage Word |  |  |  |  |  |  | baseline start none → 2002-02-13 16:00; baseline finish none → 2002-02-14 11:00 |
| 53 | Introduction à Excel |  |  |  |  |  |  | baseline start none → 2002-02-14 11:00; baseline finish none → 2002-02-14 15:00 |
| 54 | Introduction à la numérisation |  |  |  |  |  |  | baseline start none → 2002-02-14 15:00; baseline finish none → 2002-02-14 17:00 |
| 57 | **Deuxième ébauche du logiciel** | 2002-02-18 09:00 A | 2002-02-20 13:30 → 2002-02-26 17:00 (+6d) | 2.5d → 6d | 0% → 69% | 4d → 0.57d |  | baseline start none → 2002-02-18 09:00; baseline finish none → 2002-02-26 17:00 |
| 58 | Documentation des améliorations à apporter | 2002-02-18 09:00 A | 2002-02-18 13:30 → 2002-02-18 11:00 A | 3.5h → 2h | 0% → 100% | 4d → none |  | baseline start none → 2002-02-18 09:00; baseline finish none → 2002-02-18 11:00 |
| 59 | Modification des formulaires | 2002-02-18 13:30 A | 2002-02-18 17:00 → 2002-02-18 15:30 A | 3.5h → 2h | 0% → 100% | 4d → none |  | baseline start none → 2002-02-18 13:30; baseline finish none → 2002-02-18 15:30 |
| 60 | Ajout/suppresion de formulaires | 2002-02-19 09:00 A | 2002-02-19 13:30 → 2002-02-19 12:00 A | 3.5h → 3h | 0% → 100% | 4d → none |  | baseline start none → 2002-02-19 09:00; baseline finish none → 2002-02-19 12:00 |
| 65 | Finalisation du logiciel de démonstration | 2002-02-19 13:30 → 2002-02-26 09:00 (+7d) | 2002-02-19 17:00 → 2002-02-26 13:30 (+7d) |  |  | 4d → 0.57d | 60 → 69 | constraint none → start no earlier than 2002-02-26 09:00; baseline start none → 2002-02-26 09:00; baseline finish none → 2002-02-26 13:30 |
| 66 | Présentation du logiciel de démonstration corrigé | 2002-02-20 09:00 → 2002-02-26 13:30 (+6d) | 2002-02-20 13:30 → 2002-02-26 17:00 (+6d) |  |  | 4d → 0.57d |  | baseline start none → 2002-02-26 13:30; baseline finish none → 2002-02-26 17:00 |
| 71 | **Conception détaillée** | 2002-02-20 13:30 → 2002-02-21 09:00 A (+1d) | 2002-03-07 17:00 → 2002-03-11 17:00 (+4d) | 9.5d → 10d | 0% → 6% | 4d → 3d | 66 → 57 | resources Yan Morin → none; baseline start none → 2002-02-21 09:00; baseline finish none → 2002-03-11 17:00 |
| 72 | Discussion sur les rapports et accesibilité | 2002-02-20 13:30 → 2002-02-25 10:00 A (+5d) | 2002-02-20 17:00 → 2002-02-27 09:52 (+7d) |  | 0% → 75% | 4d → 8.43d |  | constraint none → start no earlier than 2002-02-21 09:00; resources none → Yan Morin; baseline start none → 2002-02-25 10:00; baseline finish none → 2002-02-27 09:52 |
| 73 | Discusion sur les requêtes | 2002-02-21 09:00 → 2002-02-27 09:52 (+6d) | 2002-02-21 13:30 → 2002-02-27 14:22 (+6d) |  |  | 4d → 8.43d |  | resources none → Yan Morin; baseline start none → 2002-02-27 09:52; baseline finish none → 2002-02-27 14:22 |
| 74 | Réflexion sur les requêtes | 2002-02-21 13:30 → 2002-02-27 14:22 (+6d) | 2002-02-21 17:00 → 2002-02-28 09:52 (+7d) |  |  | 4d → 8.43d |  | resources none → Yan Morin; baseline start none → 2002-02-27 14:22; baseline finish none → 2002-02-28 09:52 |
| 75 | Discusion sur les résultats attendus | 2002-02-25 09:00 → 2002-02-28 09:52 A (+3d) | 2002-02-25 13:30 → 2002-02-28 14:22 (+3d) |  | 0% → 10% | 4d → 8.38d |  | resources none → Yan Morin; baseline start none → 2002-02-28 09:52; baseline finish none → 2002-02-28 14:22 |
| 76 | Discusion sur le système - Infirmière | 2002-02-25 13:30 → 2002-02-21 09:00 A (-4d) | 2002-02-25 17:00 → 2002-02-21 10:00 A (-4d) | 3.5h → 1h | 0% → 100% | 4d → none |  | resources none → Yan Morin; baseline start none → 2002-02-21 09:00; baseline finish none → 2002-02-21 10:00 |
| 77 | Discusion sur le logiciel de programmation | 2002-02-26 09:00 → 2002-02-27 09:00 (+1d) | 2002-02-26 13:30 → 2002-02-27 13:30 (+1d) |  |  | 4d → 3d |  | resources none → Yan Morin; baseline start none → 2002-02-27 09:00; baseline finish none → 2002-02-27 13:30 |
| 78 | **Apprentissage** | 2002-02-26 13:30 → 2002-02-27 13:30 (+1d) | 2002-03-04 15:30 → 2002-03-05 15:30 (+1d) |  |  | 4d → 3d |  | baseline start none → 2002-02-27 13:30; baseline finish none → 2002-03-05 15:30 |
| 79 | 1- Logiciel | 2002-02-26 13:30 → 2002-02-27 13:30 (+1d) | 2002-02-26 17:00 → 2002-02-27 17:00 (+1d) |  |  | 4d → 3d |  | baseline start none → 2002-02-27 13:30; baseline finish none → 2002-02-27 17:00 |
| 80 | 2- Exemples, tutoriels | 2002-02-27 09:00 → 2002-02-28 09:00 (+1d) | 2002-02-27 13:30 → 2002-02-28 13:30 (+1d) |  |  | 4d → 3d |  | baseline start none → 2002-02-28 09:00; baseline finish none → 2002-02-28 13:30 |
| 81 | 3- Convention, normes de travail | 2002-02-27 13:30 → 2002-02-28 13:30 (+1d) | 2002-02-27 17:00 → 2002-02-28 17:00 (+1d) |  |  | 4d → 3d |  | baseline start none → 2002-02-28 13:30; baseline finish none → 2002-02-28 17:00 |
| 82 | 4- Classe | 2002-02-28 09:00 → 2002-03-04 09:00 (+4d) | 2002-02-28 13:30 → 2002-03-04 13:30 (+4d) |  |  | 4d → 3d |  | baseline start none → 2002-03-04 09:00; baseline finish none → 2002-03-04 13:30 |
| 83 | 5- Modules | 2002-02-28 13:30 → 2002-03-04 13:30 (+4d) | 2002-02-28 15:30 → 2002-03-04 15:30 (+4d) |  |  | 4d → 3d |  | baseline start none → 2002-03-04 13:30; baseline finish none → 2002-03-04 15:30 |
| 84 | 6- Composantes VB | 2002-02-28 15:30 → 2002-03-04 15:30 (+4d) | 2002-03-04 11:00 → 2002-03-05 11:00 (+1d) |  |  | 4d → 3d |  | baseline start none → 2002-03-04 15:30; baseline finish none → 2002-03-05 11:00 |

| ID | Task | Start | Finish | Total float | Other |
| --- | --- | --- | --- | --- | --- |
| 85 | 7- Accès à la base de données | 2002-03-04 11:00 → 2002-03-05 11:00 (+1d) | 2002-03-04 15:30 → 2002-03-05 15:30 (+1d) | 4d → 3d | baseline start none → 2002-03-05 11:00; baseline finish none → 2002-03-05 15:30 |
| 86 | **Base de données** | 2002-03-04 15:30 → 2002-03-05 15:30 (+1d) | 2002-03-06 17:00 → 2002-03-07 17:00 (+1d) | 4d → 3d | baseline start none → 2002-03-05 15:30; baseline finish none → 2002-03-07 17:00 |
| 87 | Structuration de la base de données | 2002-03-04 15:30 → 2002-03-05 15:30 (+1d) | 2002-03-05 09:30 → 2002-03-06 09:30 (+1d) | 4d → 3d | baseline start none → 2002-03-05 15:30; baseline finish none → 2002-03-06 09:30 |
| 88 | Ajouts des descriptions | 2002-03-05 09:30 → 2002-03-06 09:30 (+1d) | 2002-03-05 14:00 → 2002-03-06 14:00 (+1d) | 4d → 3d | baseline start none → 2002-03-06 09:30; baseline finish none → 2002-03-06 14:00 |
| 89 | Confirmité des noms | 2002-03-05 14:00 → 2002-03-06 14:00 (+1d) | 2002-03-05 16:30 → 2002-03-06 16:30 (+1d) | 4d → 3d | baseline start none → 2002-03-06 14:00; baseline finish none → 2002-03-06 16:30 |
| 90 | Valeurs par défaut/fonctions | 2002-03-05 16:30 → 2002-03-06 16:30 (+1d) | 2002-03-06 10:30 → 2002-03-07 10:30 (+1d) | 4d → 3d | baseline start none → 2002-03-06 16:30; baseline finish none → 2002-03-07 10:30 |
| 91 | Format des champs | 2002-03-06 10:30 → 2002-03-07 10:30 (+1d) | 2002-03-06 13:30 → 2002-03-07 13:30 (+1d) | 4d → 3d | baseline start none → 2002-03-07 10:30; baseline finish none → 2002-03-07 13:30 |
| 92 | Visibilité et accesibilité | 2002-03-06 13:30 → 2002-03-07 13:30 (+1d) | 2002-03-06 17:00 → 2002-03-07 17:00 (+1d) | 4d → 3d | baseline start none → 2002-03-07 13:30; baseline finish none → 2002-03-07 17:00 |
| 93 | Support technique | 2002-03-07 09:00 → 2002-03-11 09:00 (+4d) | 2002-03-07 13:30 → 2002-03-11 13:30 (+4d) | 4d → 3d | baseline start none → 2002-03-11 09:00; baseline finish none → 2002-03-11 13:30 |
| 94 | Imprévus | 2002-03-07 13:30 → 2002-03-11 13:30 (+4d) | 2002-03-07 17:00 → 2002-03-11 17:00 (+4d) | 4d → 3d | baseline start none → 2002-03-11 13:30; baseline finish none → 2002-03-11 17:00 |
| 96 | Codage | 2002-03-11 09:00 → 2002-03-12 09:00 (+1d) | 2002-04-04 17:00 → 2002-04-08 17:00 (+4d) | 4d → 3d | baseline start none → 2002-03-12 09:00; baseline finish none → 2002-04-08 17:00 |
| 98 | Test |  |  |  | baseline start none → 2002-04-15 09:00; baseline finish none → 2002-04-17 13:30 |
| 100 | Implantation |  |  |  | baseline start none → 2002-04-17 13:30; baseline finish none → 2002-04-22 17:00 |
| 102 | Vérification et documentation |  |  |  | baseline start none → 2002-04-23 09:00; baseline finish none → 2002-05-02 17:00 |
